# Iceberg Astep timeline

Schedule from MS Project, 2007-03-01 to 2011-03-25.
MBARI

## Calendars

- Standard: Mon-Fri 08:00-12:00, 13:00-17:00; Sat-Sun off.

## Resources

| Resource |
| --- |
| ME1 |
| MS |
| ME Tech |
| EE Tech |
| EE1 |
| AUV Specialist |
| SE1 |
| SE2 |
| Ideal Instrument |
| vendor |

## Schedule

| ID | WBS | Task | Duration | Start | Finish | Total slack | Resources | Work |
| --- | --- | --- | --- | --- | --- | --- | --- | --- |
| 2 | 1 | **AUV Fabrication** | 40d | 2011-01-03 08:00 | 2011-02-25 17:00 | 20d |  | 1315.41h |
| 3 | 1.1 | **SubSystem Ordering/Fabrication** | 40d | 2011-01-03 08:00 | 2011-02-25 17:00 | 20d |  | 561.49h |
| 4 | 1.1.1 | **Pressure Vessel Fabrication** | 0.56d | 2011-01-03 08:00 | 2011-01-03 13:30 | 59.44d |  | 13.5h |
| 5 | 1.1.1.1 | **MVC Sphere** | 0.56d | 2011-01-03 08:00 | 2011-01-03 13:30 | 59.44d |  | 6.75h |
| 6 | 1.1.1.1.1 | Quoting & Ordering Benthos sphere | 0.28d | 2011-01-03 08:00 | 2011-01-03 10:15 | 19.72d | ME Tech | 2.25h |
| 7 | 1.1.1.1.2 | Penetrator/dummy kitting for pressure test | 0.56d | 2011-01-03 08:00 | 2011-01-03 13:30 | 19.44d | ME Tech | 4.5h |
| 8 | 1.1.1.2 | **Nose DCON** | 0.56d | 2011-01-03 08:00 | 2011-01-03 13:30 | 59.44d |  | 6.75h |
| 9 | 1.1.1.2.1 | Quoting & ordering housing | 0.28d | 2011-01-03 08:00 | 2011-01-03 10:15 | 19.72d | ME Tech | 2.25h |
| 10 | 1.1.1.2.2 | Penetrator/dummy kitting for pressure test | 0.56d | 2011-01-03 08:00 | 2011-01-03 13:30 | 19.44d | ME Tech | 4.5h |
| 11 | 1.1.2 | **Fairing Fabrication/Holes** | 1.12d | 2011-01-03 08:00 | 2011-01-04 09:00 | 58.88d |  | 27h |
| 12 | 1.1.2.1 | Tail Fairing | 1.12d | 2011-01-03 08:00 | 2011-01-04 09:00 | 18.88d | ME Tech | 9h |
| 13 | 1.1.2.2 | Nose Fairing | 1.12d | 2011-01-03 08:00 | 2011-01-04 09:00 | 18.88d | ME Tech | 9h |
| 14 | 1.1.2.3 | MidSection Faiiring | 1.12d | 2011-01-03 08:00 | 2011-01-04 09:00 | 18.88d | ME Tech | 9h |
| 15 | 1.1.3 | **Wet Cabling Fabrication** | 0.56d | 2011-01-03 08:00 | 2011-01-03 13:30 | 59.44d |  | 68.24h |
| 16 | 1.1.3.1 | C/F Kitting for Seaconn | 0.56d | 2011-01-03 08:00 | 2011-01-03 13:30 | 19.44d | EE Tech | 4.5h |
| 17 | 1.1.3.2 | C/F Kitting for Subconn | 0.56d | 2011-01-03 08:00 | 2011-01-03 13:30 | 19.44d | EE Tech | 4.5h |
| 18 | 1.1.3.3 | C/F Kitting for Impulse | 0.56d | 2011-01-03 08:00 | 2011-01-03 13:30 | 19.44d | EE Tech | 4.5h |
| 19 | 1.1.3.4 | MVC Forward Bus Cable | 0.11d | 2011-01-03 08:00 | 2011-01-03 08:54 | 19.89d | EE Tech | 0.9h |
| 20 | 1.1.3.5 | MVC Shore Tether Cable | 0.56d | 2011-01-03 08:00 | 2011-01-03 13:28 | 59.44d | EE Tech | 4.48h |
| 21 | 1.1.3.6 | MVC/TailCone Cable | 0.56d | 2011-01-03 08:00 | 2011-01-03 13:28 | 59.44d | EE Tech | 4.48h |
| 22 | 1.1.3.7 | MVC/DVL Cable | 0.56d | 2011-01-03 08:00 | 2011-01-03 13:28 | 59.44d | EE Tech | 4.48h |
| 23 | 1.1.3.8 | MVC/Pressure Sensor Cable | 0.56d | 2011-01-03 08:00 | 2011-01-03 13:28 | 59.44d | EE Tech | 4.48h |
| 24 | 1.1.3.9 | Battery JBOX Aft Cable | 0.56d | 2011-01-03 08:00 | 2011-01-03 13:28 | 59.44d | EE Tech | 4.48h |
| 25 | 1.1.3.10 | Battery JBOX Forward Cable | 0.56d | 2011-01-03 08:00 | 2011-01-03 13:28 | 59.44d | EE Tech | 4.48h |
| 26 | 1.1.3.11 | Science DCON Aft Cable | 0.56d | 2011-01-03 08:00 | 2011-01-03 13:28 | 59.44d | EE Tech | 4.48h |
| 27 | 1.1.3.12 | CTD1 Cable | 0.56d | 2011-01-03 08:00 | 2011-01-03 13:28 | 59.44d | EE Tech | 4.48h |
| 28 | 1.1.3.13 | CTD2 Cable | 0.56d | 2011-01-03 08:00 | 2011-01-03 13:30 | 19.44d | EE Tech | 4.5h |
| 29 | 1.1.3.14 | DO Sensor Cable | 0.56d | 2011-01-03 08:00 | 2011-01-03 13:30 | 19.44d | EE Tech | 4.5h |
| 30 | 1.1.3.15 | ISUS Cable | 0.56d | 2011-01-03 08:00 | 2011-01-03 13:30 | 19.44d | EE Tech | 4.5h |
| 31 | 1.1.3.16 | Flow Sensor Cable | 0.56d | 2011-01-03 08:00 | 2011-01-03 13:30 | 19.44d | EE Tech | 4.5h |

| ID | WBS | Task | Duration | Start | Finish | Predecessors | Total slack | Free slack | Resources | Work |
| --- | --- | --- | --- | --- | --- | --- | --- | --- | --- | --- |
| 32 | 1.1.4 | **Syntactic Fabrication** | 40d | 2011-01-03 08:00 | 2011-02-25 17:00 |  | 20d |  |  | 330.25h |
| 33 | 1.1.4.1 | Drawing Package Preparation | 1d | 2011-01-03 08:00 | 2011-01-03 17:00 |  | 19d |  | ME1 | 8h |
| 34 | 1.1.4.2 | Vendor Quoting/Contracting | 0.28d | 2011-01-03 08:00 | 2011-01-03 10:15 |  | 19.72d |  | ME Tech | 2.25h |
| 35 | 1.1.4.3 | Syntactic Module Fabrication | 40d | 2011-01-03 08:00 | 2011-02-25 17:00 |  | 20d |  | Ideal Instrument | 320h |
| 36 | 1.1.5 | **Custom Printed Circuit Board Fabrication** | 10d | 2011-01-03 08:00 | 2011-01-14 17:00 |  | 50d |  |  | 122.5h |
| 37 | 1.1.5.1 | **MVC Power Board Fabrication** | 10d | 2011-01-03 08:00 | 2011-01-14 17:00 |  | 50d |  |  | 118.5h |
| 38 | 1.1.5.1.1 | Upgrade design | 10d | 2011-01-03 08:00 | 2011-01-14 17:00 |  | 50d |  | EE1 | 80h |
| 39 | 1.1.5.1.2 | Component ordering | 2d | 2011-01-03 08:00 | 2011-01-04 17:00 |  | 58d |  | EE Tech | 16h |
| 40 | 1.1.5.1.3 | Component installation | 2.25d | 2011-01-03 08:00 | 2011-01-05 10:00 |  | 57.75d |  | EE Tech | 18h |
| 41 | 1.1.5.1.4 | Burn-in & test | 0.56d | 2011-01-03 08:00 | 2011-01-03 13:30 |  | 59.44d |  | EE Tech | 4.5h |
| 42 | 1.1.5.2 | Junction Box PCB Fabrication | 0.5d | 2011-01-03 08:00 | 2011-01-03 12:00 |  | 59.5d |  | EE Tech | 4h |
| 43 | 1.2 | **Tail Section Electrical/Mechanical Integration & Test** | 21.86d | 2011-01-03 08:00 | 2011-02-01 15:55 |  | 38.13d |  |  | 364.42h |
| 44 | 1.2.1 | **Tail Bracketry Fabrication** | 4.5d | 2011-01-03 08:00 | 2011-01-07 12:00 |  | 50.5d | 12.37d |  | 90h |
| 45 | 1.2.1.1 | Forward Plate | 1.12d | 2011-01-03 08:00 | 2011-01-04 09:00 |  | 53.88d |  | ME Tech | 9h |
| 46 | 1.2.1.2 | Bottom Plate | 2.25d | 2011-01-03 08:00 | 2011-01-05 10:00 |  | 52.75d |  | ME Tech | 18h |
| 47 | 1.2.1.3 | Aft Plate | 1.12d | 2011-01-03 08:00 | 2011-01-04 09:00 |  | 53.88d |  | ME Tech | 9h |
| 48 | 1.2.1.4 | Mounting Clamps (DVL,parosci,homerpro,xpndr) | 4.5d | 2011-01-03 08:00 | 2011-01-07 12:00 |  | 50.5d |  | ME Tech | 36h |
| 49 | 1.2.1.5 | Antenna/strobe mount | 2.25d | 2011-01-03 08:00 | 2011-01-05 10:00 |  | 52.75d |  | ME Tech | 18h |
| 50 | 1.2.2 | Propulsion Integration/Installation | 5.62d | 2011-01-03 08:00 | 2011-01-10 14:00 |  | 49.38d | 11.24d | ME Tech | 45h |
| 51 | 1.2.3 | **MVC Sphere/Dry Integation** | 16.86d | 2011-01-03 08:00 | 2011-01-25 15:55 |  | 38.13d | 0d |  | 134.92h |
| 52 | 1.2.3.1 | Threaded Insert Frame Fabrication | 1.12d | 2011-01-03 08:00 | 2011-01-04 09:00 |  | 38.13d | 0d | ME Tech | 9h |
| 53 | 1.2.3.2 | Urethane Base Molding | 1.12d | 2011-01-04 09:00 | 2011-01-05 10:00 | 52 | 38.13d | 0d | ME Tech | 9h |
| 54 | 1.2.3.3 | Mounting Plate Installation | 1.12d | 2011-01-05 10:00 | 2011-01-06 11:00 | 53 | 38.13d | 0d | ME Tech | 9h |
| 55 | 1.2.3.4 | PC104 Stack Intallation | 0.56d | 2011-01-06 11:00 | 2011-01-06 16:28 | 54 | 38.13d | 0d | EE Tech | 4.48h |
| 56 | 1.2.3.5 | Novatech Installation | 0.56d | 2011-01-06 16:28 | 2011-01-07 11:57 | 55 | 38.13d | 0d | ME Tech | 4.48h |
| 57 | 1.2.3.6 | GPS Installation | 0.56d | 2011-01-07 11:57 | 2011-01-10 08:26 | 56 | 38.13d | 0d | EE Tech | 4.48h |
| 58 | 1.2.3.7 | Heading Reference Installation | 0.56d | 2011-01-10 08:26 | 2011-01-10 13:55 | 57 | 38.13d | 0d | EE Tech | 4.48h |
| 59 | 1.2.3.8 | RF Penetrator Installation/Wiring | 0.56d | 2011-01-10 13:55 | 2011-01-11 09:25 | 58 | 38.13d | 0d | EE Tech | 4.5h |
| 60 | 1.2.3.9 | MINK Penetrator Installation/Wiring | 2.25d | 2011-01-11 09:25 | 2011-01-13 11:25 | 59 | 38.13d | 0d | EE Tech | 18h |
| 61 | 1.2.3.10 | LPBH Installation/Wiring | 2.25d | 2011-01-13 11:25 | 2011-01-17 14:25 | 60 | 38.13d | 0d | EE Tech | 18h |
| 62 | 1.2.3.11 | MVC Power Board Installation | 0.56d | 2011-01-17 14:25 | 2011-01-18 09:55 | 61 | 38.13d | 0d | EE Tech | 4.5h |
| 63 | 1.2.3.12 | Point-to-Point Wiring Installation | 5.62d | 2011-01-18 09:55 | 2011-01-25 15:55 | 62 | 38.13d |  | EE Tech | 45h |

| ID | WBS | Task | Duration | Start | Finish | Predecessors | Total slack | Free slack | Resources | Work |
| --- | --- | --- | --- | --- | --- | --- | --- | --- | --- | --- |
| 64 | 1.2.4 | **Mechanical/Wet Integration** | 2.97d | 2011-01-03 08:00 | 2011-01-05 16:45 |  | 52.03d | 13.9d |  | 31.75h |
| 65 | 1.2.4.1 | Mount Sphere to base plate | 1.12d | 2011-01-03 08:00 | 2011-01-04 09:00 |  | 52.03d | 0d | ME Tech | 9h |
| 66 | 1.2.4.2 | Mount/cable Parosci, HomerPro | 0.28d | 2011-01-04 09:00 | 2011-01-04 11:15 | 65 | 52.03d | 0d | ME Tech | 2.25h |
| 67 | 1.2.4.3 | Mount USBL Beacon/Transducer | 0.28d | 2011-01-04 11:15 | 2011-01-04 14:30 | 66 | 52.03d | 0d | ME Tech | 2.25h |
| 68 | 1.2.4.4 | Mount/Cable SeaDevel | 1d | 2011-01-04 14:30 | 2011-01-05 14:30 | 67 | 52.03d | 0d | ME Tech; ME1 | 16h |
| 69 | 1.2.4.5 | Syntactic Installation | 0.28d | 2011-01-05 14:30 | 2011-01-05 16:45 | 68 | 52.03d |  | ME Tech | 2.25h |
| 70 | 1.2.5 | **Functional test of Tail Section sub-systems** | 5d | 2011-01-25 15:55 | 2011-02-01 15:55 | 44, 50, 51, 64 | 38.13d |  |  | 62.75h |
| 71 | 1.2.5.1 | SeaDevil powerup and alignment | 2d | 2011-01-25 15:55 | 2011-01-27 15:55 |  | 41.13d |  | AUV Specialist | 16h |
| 72 | 1.2.5.2 | SeaDevil software integration | 5d | 2011-01-25 15:55 | 2011-02-01 15:55 |  | 38.13d |  | AUV Specialist | 40h |
| 73 | 1.2.5.3 | Tailcone Calibration | 0.28d | 2011-01-25 15:55 | 2011-01-26 09:10 |  | 42.29d | 0d | ME Tech | 2.25h |
| 74 | 1.2.5.4 | Parosci Test | 0.28d | 2011-01-26 09:10 | 2011-01-26 11:25 | 73 | 42.29d | 0d | EE Tech | 2.25h |
| 75 | 1.2.5.5 | Compass comms test | 0.28d | 2011-01-26 11:25 | 2011-01-26 14:40 | 74 | 42.29d |  | EE Tech | 2.25h |
| 76 | 1.3 | **Mid Section Electrical/Mechanical Integration & Test** | 5d | 2011-01-03 08:00 | 2011-01-07 17:00 |  | 55d |  |  | 149.5h |
| 77 | 1.3.1 | **Bracketry** | 5d | 2011-01-03 08:00 | 2011-01-07 17:00 |  | 55d |  |  | 58h |
| 78 | 1.3.1.1 | Bracketry Fabrication | 5d | 2011-01-03 08:00 | 2011-01-07 17:00 |  | 55d |  | ME Tech | 40h |
| 79 | 1.3.1.2 | Bracketry assembly | 2.25d | 2011-01-03 08:00 | 2011-01-05 10:00 |  | 57.75d |  | ME Tech | 18h |
| 80 | 1.3.2 | Syntactic Assembly | 1.12d | 2011-01-03 08:00 | 2011-01-04 09:00 |  | 58.88d |  | ME Tech | 9h |
| 81 | 1.3.3 | **Battery** | 2.25d | 2011-01-03 08:00 | 2011-01-05 10:00 |  | 57.75d |  |  | 51h |
| 82 | 1.3.3.1 | component ordering | 1d | 2011-01-03 08:00 | 2011-01-03 17:00 |  | 59d |  | EE Tech | 8h |
| 83 | 1.3.3.2 | Assembly | 2d | 2011-01-03 08:00 | 2011-01-04 17:00 |  | 58d |  | EE Tech | 16h |
| 84 | 1.3.3.3 | Bench testing | 2.25d | 2011-01-03 08:00 | 2011-01-05 10:00 |  | 57.75d |  | EE Tech | 18h |
| 85 | 1.3.3.4 | Installation | 1.12d | 2011-01-03 08:00 | 2011-01-04 09:00 |  | 58.88d |  | EE Tech | 9h |
| 86 | 1.3.4 | **junction Box** | 2.25d | 2011-01-03 08:00 | 2011-01-05 10:00 |  | 57.75d |  |  | 31.5h |
| 87 | 1.3.4.1 | Assembly | 2.25d | 2011-01-03 08:00 | 2011-01-05 10:00 |  | 57.75d |  | ME Tech | 18h |
| 88 | 1.3.4.2 | Casting | 1.12d | 2011-01-03 08:00 | 2011-01-04 09:00 |  | 58.88d |  | ME Tech | 9h |
| 89 | 1.3.4.3 | Installation | 0.56d | 2011-01-03 08:00 | 2011-01-03 13:30 |  | 59.44d |  | ME Tech | 4.5h |
| 90 | 1.4 | Nose Section Electrical/Mechanical Integration & Test | 10d | 2011-01-03 08:00 | 2011-01-14 17:00 |  | 50d |  | ME Tech; EE Tech; SE2 | 240h |

| ID | WBS | Task | Duration | Start | Finish | Total slack | Resources | Work |
| --- | --- | --- | --- | --- | --- | --- | --- | --- |
| 91 | 2 | **Hovering module** | 60d | 2011-01-03 08:00 | 2011-03-25 17:00 | 0d |  | 920h |
| 92 | 2.1 | Spec thrusters and controllers | 5d | 2011-01-03 08:00 | 2011-01-07 17:00 | 55d | ME1 | 40h |
| 93 | 2.2 | Order thrusters and controllers | 60d | 2011-01-03 08:00 | 2011-03-25 17:00 | 0d | vendor | 480h |
| 94 | 2.3 | Design mounts and ducts | 2d | 2011-01-03 08:00 | 2011-01-04 17:00 | 58d | ME1 | 16h |
| 95 | 2.4 | Design into electrical system | 15d | 2011-01-03 08:00 | 2011-01-21 17:00 | 45d | EE1 | 120h |
| 96 | 2.5 | Integrate ducts and cabling into hull | 4d | 2011-01-03 08:00 | 2011-01-06 17:00 | 56d | ME1 | 32h |
| 97 | 2.6 | Spec and order duct tubing | 4d | 2011-01-03 08:00 | 2011-01-06 17:00 | 56d | ME1 | 32h |
| 98 | 2.7 | machine ducts | 10d | 2011-01-03 08:00 | 2011-01-14 17:00 | 50d | MS | 80h |
| 99 | 2.8 | integrate thrusters | 3d | 2011-01-03 08:00 | 2011-01-05 17:00 | 57d | ME Tech | 24h |
| 100 | 2.9 | Wet cabling fabrication | 2d | 2011-01-03 08:00 | 2011-01-04 17:00 | 58d | EE Tech | 16h |
| 101 | 2.10 | Design controller housing | 5d | 2011-01-03 08:00 | 2011-01-07 17:00 | 55d | ME1 | 40h |
| 102 | 2.11 | build module | 5d | 2011-01-03 08:00 | 2011-01-07 17:00 | 55d | ME Tech | 40h |
| 103 | 3 | **Sonar Module** | 60d | 2011-01-03 08:00 | 2011-03-25 17:00 | 0d |  | 264h |
| 104 | 3.1 | spec MB sonar | 3d | 2011-01-03 08:00 | 2011-01-05 17:00 | 57d | AUV Specialist | 24h |
| 105 | 3.2 | order | 60d | 2011-01-03 08:00 | 2011-03-25 17:00 | 0d |  |  |
| 106 | 3.3 | design mounts | 5d | 2011-01-03 08:00 | 2011-01-07 17:00 | 55d | ME1 | 40h |
| 107 | 3.4 | Design power, comms, triggering | 5d | 2011-01-03 08:00 | 2011-01-07 17:00 | 55d | AUV Specialist | 40h |
| 108 | 3.5 | integrate | 10d | 2011-01-03 08:00 | 2011-01-14 17:00 | 50d | AUV Specialist | 80h |
| 109 | 3.6 | Test | 10d | 2011-01-03 08:00 | 2011-01-14 17:00 | 50d | AUV Specialist | 80h |
| 110 | 4 | **Control system** | 30d | 2011-01-03 08:00 | 2011-02-11 17:00 | 30d |  | 1040h |
| 111 | 4.1 | Design hovering controllers | 30d | 2011-01-03 08:00 | 2011-02-11 17:00 | 30d | SE1 | 240h |
| 112 | 4.2 | Write code to control hovering thrusters | 20d | 2011-01-03 08:00 | 2011-01-28 17:00 | 40d | SE2 | 160h |
| 113 | 4.3 | Integrate hovering and cruise control | 20d | 2011-01-03 08:00 | 2011-01-28 17:00 | 40d | SE1 | 160h |
| 114 | 4.4 | Build simulator | 20d | 2011-01-03 08:00 | 2011-01-28 17:00 | 40d | SE1 | 160h |
| 115 | 4.5 | test contollers with sim | 20d | 2011-01-03 08:00 | 2011-01-28 17:00 | 40d | SE1 | 160h |
| 116 | 4.6 | re-work | 20d | 2011-01-03 08:00 | 2011-01-28 17:00 | 40d | SE1 | 160h |
| 117 | 5 | Project management | 20d | 2011-01-03 08:00 | 2011-01-28 17:00 | 40d | ME1 | 160h |

| ID | WBS | Task | Duration | Start | Finish | Total slack | Constraint | Resources | Work |
| --- | --- | --- | --- | --- | --- | --- | --- | --- | --- |
| 119 | 6 | **Operations** | 1017d | 2007-03-01 08:00 | 2011-01-21 17:00 | 45d |  |  | 2520h |
| 120 | 6.1 | Tank Testing | 15d | 2011-01-03 08:00 | 2011-01-21 17:00 | 45d |  | ME Tech; ME1; EE1; SE1; AUV Specialist | 600h |
| 121 | 6.2 | MB tests | 10d | 2007-03-01 08:00 | 2007-03-14 17:00 | 1052d | start no earlier than 2007-03-01 08:00 | AUV Specialist; ME Tech; ME1; EE1; SE1 | 400h |
| 122 | 6.3 | MB tests 2 | 10d | 2007-09-03 08:00 | 2007-09-14 17:00 | 920d | start no earlier than 2007-09-03 08:00 | ME1; SE1; AUV Specialist | 240h |
| 123 | 6.4 | trip 1 | 53.33d | 2008-08-04 08:00 | 2008-10-16 10:40 | 636.67d | start no earlier than 2008-08-04 08:00 | ME1; SE1; AUV Specialist | 1280h |

Notes:
- 122: Northern hemi development tests
